Schedule from MS Project, 2007-02-10 to 2008-05-03, 5 hours a day, A marks actual dates.

## Calendars

- Weekend Project: Mon-Fri off; Sat-Sun 09:00-12:00, 13:00-15:00. Exceptions (off unless hours are given): 2007-02-12 to 2007-02-16, 2007-02-19 to 2007-02-23, 2007-02-26 to 2007-02-28, 2007-04-08, 2007-05-20, 2007-06-23 to 2007-06-24.

## Resources

| Resource |
| --- |
| Rog |
| Plumber |
| H & C Dude |
| American Egress |
| Electrician |
| Ceiling dudes |
| Carpet dudes |

## Schedule

| ID | WBS | Task | Duration | Start | Finish | Predecessors | Complete | Remaining | Total slack | Free slack | Resources | Work | Actual work |
| --- | --- | --- | --- | --- | --- | --- | --- | --- | --- | --- | --- | --- | --- |
| 1 | 1 | **Basement Prep** | 15.2d | 2007-02-10 09:00 A | 2007-04-01 10:00 |  | 84% | 2.49d | 9.71d | 0d |  | 64h | 53.5h |
| 2 | 1.1 | Clean out work room | 5h | 2007-02-10 09:00 A | 2007-02-10 15:00 A |  | 100% |  |  |  | Rog | 5h | 5h |
| 3 | 1.2 | Clean out storage area | 10h | 2007-02-11 09:00 A | 2007-02-17 15:00 A | 2 | 100% |  |  |  | Rog | 10h | 10h |
| 4 | 1.3 | Move plumbing | 2h | 2007-03-25 09:00 A | 2007-03-25 11:00 A | 3FS+10d | 100% |  |  |  | Plumber | 2h | 2h |
| 5 | 1.4 | Move HVAC | 2h | 2007-03-25 11:00 A | 2007-03-25 14:00 A | 4 | 100% |  |  |  | H & C Dude | 2h | 2h |
| 6 | 1.5 | Clean out office area | 5h | 2007-02-24 09:00 A | 2007-02-24 15:00 | 3FS+1d | 90% | 0.5h | 19.91d |  | Rog | 5h | 4.5h |
| 7 | 1.6 | Move washer & stove to garage | 5h | 2007-02-25 09:00 A | 2007-02-25 15:00 A | 6 | 100% |  |  |  | Rog | 5h | 5h |
| 8 | 1.7 | Remove walls in work room | 10h | 2007-03-03 09:00 A | 2007-03-04 15:00 A | 7 | 100% |  |  |  | Rog | 10h | 10h |
| 9 | 1.8 | Empty book case & misc. cleaning | 10h | 2007-03-10 09:00 A | 2007-03-11 15:00 A | 8 | 100% |  |  |  | Rog | 10h | 10h |
| 10 | 1.9 | Glass block windows installed (3) | 1d | 2007-03-25 14:00 | 2007-03-31 10:00 | 5 |  |  | 0.9d | 0d | American Egress | 5h |  |
| 11 | 1.10 | Egress window installed | 1d | 2007-03-31 10:00 | 2007-03-31 16:00 | 10 |  |  | 1d |  | American Egress | 5h |  |
| 12 | 1.11 | Repair wall crack | 5h | 2007-03-31 10:00 A | 2007-04-01 10:00 A | 10 | 100% |  |  |  | Rog | 5h | 5h |
| 13 | 2 | **Build** | 108.2d | 2007-04-07 10:00 A | 2008-05-03 11:00 | 1FS+1d | 13% | 93.97d | 0d |  | Rog | 1115h | 139.16h |
| 14 | 2.1 | **Walls by furnace** | 5d | 2007-04-07 10:00 A | 2007-04-28 10:00 A |  | 100% |  |  |  |  | 25h | 25h |
| 15 | 2.1.1 | Purchase studs and nails | 5h | 2007-04-07 10:00 A | 2007-04-14 10:00 A |  | 100% |  |  |  | Rog | 5h | 5h |
| 16 | 2.1.2 | Frame in walls (4 sections) & storage room door | 20h | 2007-04-14 10:00 A | 2007-04-28 10:00 A | 15 | 100% |  |  |  | Rog | 20h | 20h |
| 17 | 2.2 | **Walls Phase 2** | 21.8d | 2007-05-12 10:00 A | 2007-08-04 15:00 | 14FS+2d | 39% | 13.28d | 1d | 0d |  | 110h | 43h |
| 18 | 2.2.1 | Purchase studs and nails | 5h | 2007-05-12 10:00 A | 2007-05-13 10:00 |  | 50% | 2.5h | 5.58d | 0d | Rog | 5h | 2.5h |
| 19 | 2.2.2 | Frame in walls & doors (18 sections) | 90h | 2007-05-13 10:00 A | 2007-07-28 10:00 | 18 | 45% | 49.5h | 1.8d |  | Rog | 90h | 40.5h |
| 20 | 2.2.3 | Electrical rough-in | 2d | 2007-07-30 08:00 | 2007-07-31 10:00 | 19 |  |  | 0d |  | Electrician | 10h |  |
| 21 | 2.2.4 | **HT Wiring** | 1d | 2007-08-04 09:00 | 2007-08-04 15:00 | 20 |  |  | 1d |  |  | 5h |  |
| 22 | 2.2.4.1 | Run PVC & Speaker wire, HDMI cable, etc. | 5h | 2007-08-04 09:00 | 2007-08-04 15:00 |  |  |  | 1d |  | Rog | 5h |  |
| 23 | 2.3 | **Walls Phase 3** | 51d | 2007-08-05 09:00 | 2008-01-27 15:00 | 17 |  |  | 1d | 0d |  | 255h |  |
| 24 | 2.3.1 | Purchase drywall & insulation | 5h | 2007-08-05 09:00 | 2007-08-05 15:00 |  |  |  | 1d | 0d |  |  |  |
| 25 | 2.3.2 | Drywall & Insulate walls (18 sections) | 140h | 2007-08-11 09:00 | 2007-11-11 15:00 | 24 |  |  | 1d | 0d | Rog | 140h |  |
| 26 | 2.3.3 | Hang doors (3) | 15h | 2007-11-17 09:00 | 2007-11-24 15:00 | 25 |  |  | 1d | 0d | Rog | 15h |  |
| 27 | 2.3.4 | Tape, mud & sand | 60h | 2007-11-25 09:00 | 2008-01-05 15:00 | 26 |  |  | 1d | 0d | Rog | 60h |  |
| 28 | 2.3.5 | Prime | 20h | 2008-01-06 09:00 | 2008-01-19 15:00 | 27 |  |  | 1d | 0d | Rog | 20h |  |
| 29 | 2.3.6 | Finish electrical | 10h | 2008-01-21 08:00 | 2008-01-22 10:00 | 28 |  |  | 0d |  | Electrician | 10h |  |
| 30 | 2.3.7 | Insulate ceiling | 10h | 2008-01-26 09:00 | 2008-01-27 15:00 | 29 |  |  | 1d |  |  |  |  |
| 31 | 2.3.8 | Install cabinetry | 10h | 2008-01-20 09:00 | 2008-01-26 15:00 | 28 |  |  | 2d |  | Rog | 10h |  |

Notes:
- 19: 18 sections of drywall / 1 office door / 1 closet door / 2 posts
- 20: 3-4 new circuits / 15 can lights / Dimmers on all switches / ~15 outlets

| ID | WBS | Task | Duration | Start | Finish | Predecessors | Total slack | Free slack | Resources | Work |
| --- | --- | --- | --- | --- | --- | --- | --- | --- | --- | --- |
| 32 | 2.4 | **Molding and beadboard** | 13d | 2008-02-02 09:00 | 2008-03-15 15:00 | 23 | 1d | 0d | Rog | 125h |
| 33 | 2.4.1 | Purchase molding, beadboard, baseboard | 5h | 2008-02-02 09:00 | 2008-02-02 15:00 |  | 1d | 0d |  |  |
| 34 | 2.4.2 | beadboard | 20h | 2008-02-03 09:00 | 2008-02-16 15:00 | 33 | 1d | 0d | Rog | 20h |
| 35 | 2.4.3 | baseboard | 20h | 2008-02-17 09:00 | 2008-03-01 15:00 | 34 | 1d | 0d | Rog | 20h |
| 36 | 2.4.4 | chair rail | 20h | 2008-03-02 09:00 | 2008-03-15 15:00 | 35 | 1d |  | Rog | 20h |
| 37 | 2.5 | **Finishing** | 7d | 2008-03-23 09:00 | 2008-04-14 14:00 | 32FS+2d | 0d |  |  | 35h |
| 38 | 2.5.1 | Painting | 25h | 2008-03-23 09:00 | 2008-04-06 15:00 |  | 1d | 0d | Rog | 25h |
| 39 | 2.5.2 | Ceiling | 1d | 2008-04-12 09:00 | 2008-04-12 15:00 | 38 | 1d |  | Ceiling dudes | 5h |
| 40 | 2.5.3 | Carpeting | 1d | 2008-04-14 08:00 | 2008-04-14 14:00 | 39 | 0d |  | Carpet dudes | 5h |
| 41 | 2.6 | **Home Theater Install** | 2.4d | 2008-04-26 09:00 | 2008-05-03 11:00 | 37FS+2d | 0d |  | Rog | 24h |
| 42 | 2.6.1 | Projector | 5h | 2008-04-26 09:00 | 2008-04-26 15:00 |  | 0d |  | Rog | 5h |
| 43 | 2.6.2 | Speakers | 5h | 2008-04-27 09:00 | 2008-04-27 15:00 | 42 | 0d |  | Rog | 5h |
| 44 | 2.6.3 | Receiver | 1h | 2008-05-03 09:00 | 2008-05-03 10:00 | 43 | 0d |  | Rog | 1h |
| 45 | 2.6.4 | DVD | 1h | 2008-05-03 10:00 | 2008-05-03 11:00 | 44 | 0d |  | Rog | 1h |
